# PLAZO TOTAL SUB PROYECTO A1-RÍO LACRAMARCA rev.03

Schedule from Primavera P6, 2023-12-04 to 2024-06-25, data date 2023-12-03.

## Calendars

- EFECTIVOS REV.03: Mon-Sat 07:00-16:00; Sun off. Exceptions (off unless hours are given): 2023-12-08 to 2023-12-09, 2023-12-25, 2024-01-01, 2024-03-28 to 2024-03-29, 2024-04-06 08:00-16:00, 2024-05-01.
- DIAS CALENDARIOS REV.03: Mon-Sun 07:00-16:00.

## Resources

| Resource | Group | Notes |
| --- | --- | --- |
| Camión grua | labor | ï»¿ |
| CAPATAZ | labor | ï»¿ |
| OPERARIO | labor | ï»¿ |
| PEON | labor | ï»¿ |
| Camión Cisterna 4x2 400 HP Agua (5000 gal) | labor | ï»¿ |
| CUADRADOR/VIGÍA | labor | ï»¿ |
| Motoniveladora 185 HP | labor | ï»¿ |
| Retroexcavador 58 HP | labor | ï»¿ |
| Rodillo Vib. Liso Autopropulsado 135 HP 12 TM | labor | ï»¿ |
| Excavadora Sobre Oruga 260 HP | labor | ï»¿ |
| Tractor S/Orugas (D6T) - 180 HP | labor | ï»¿ |
| OFICIAL | labor | ï»¿ |
| Excavadora + Martillo hidraúlico | labor | ï»¿ |
| Camión Volquete (15 m3) | labor | ï»¿ |
| CARGADOR SOBRE LLANTAS DE 200-250 HP | labor | ï»¿ |
| Camión Volquete Roquero (15 m3) | labor | ï»¿ |
| Excavadora Sobre Oruga 320 | labor | ï»¿ |
| AYUDANTE DE NIVELADOR | labor | ï»¿ |
| AYUDANTE DE TOPOGRAFO | labor | ï»¿ |
| TOPOGRAFO | labor | ï»¿ |
| OP. NIVELADOR | labor | ï»¿ |

## Schedule

| ID | WBS | Activity | Type | Duration | Start | Finish | Predecessors | Total float | Free float | Calendar | Resources |
| --- | --- | --- | --- | --- | --- | --- | --- | --- | --- | --- | --- |
|  | 1 | **HITOS** |  |  | 2023-12-04 | 2023-12-18 |  |  |  |  |  |
| A1020 |  | KICK OF MEETING (KMO) | milestone | 0d | 2023-12-04 | 2023-12-04 |  | 0d |  | DIAS CALENDARIOS REV.03 |  |
| A1025 |  | MOVILIZACION DE EQUIPOS |  | 15d | 2023-12-04 | 2023-12-18 | A1020 SS | 0d |  | DIAS CALENDARIOS REV.03 |  |
| A1070 |  | INICIO DE MOVILIZACION DE EQUIPOS | milestone | 0d | 2023-12-04 | 2023-12-04 |  | 35d |  | DIAS CALENDARIOS REV.03 |  |
|  | 2 | **PLAZO DE EJECUCIÓN CONSTRUCCIÓN SUB PROYECTO A1-RÍO LACRAMARCA-1** |  |  | 2023-12-19 | 2024-06-25 |  |  |  |  |  |
| A1030 |  | INICIO DEL PLAZO CONTRACTUAL - ACCESO AL SITIO | milestone | 0d | 2023-12-19 | 2023-12-19 | A1025 SS+15d | 0d |  | DIAS CALENDARIOS REV.03 |  |
| A1040 |  | INICIO DE EXCAVACIÓN | milestone | 0d | 2024-01-08 | 2024-01-08 | A1030 SS+20d, A1070 SS | 0d |  | DIAS CALENDARIOS REV.03 |  |
| A1054 |  | INICIO DE DIQUE MARGEN IZQUIERDA | milestone | 0d | 2024-01-08 | 2024-01-08 | A1040 SS | 23.91d | 0d | DIAS CALENDARIOS REV.03 |  |
| A1055 |  | INICIO DE DIQUE MARGEN DERECHA | milestone | 0d | 2024-01-11 | 2024-01-11 | A1054 SS+3d | 23.91d | 0d | DIAS CALENDARIOS REV.03 |  |
| A1050 |  | INICIO DE RELLENO DE DIQUE | milestone | 0d | 2024-01-17 | 2024-01-17 | A1040 SS+9d | 12.3d | 4d | DIAS CALENDARIOS REV.03 |  |
| A1059 |  | FIN DE DIQUE MARGEN DERECHA | milestone | 0d | 2024-05-09 | 2024-05-09 | A1055 SF+120d | 46.91d |  | DIAS CALENDARIOS REV.03 |  |
| A1056 |  | INICIO DE DIQUE LIBERACIÓN PREDIAL LD | milestone | 0d | 2024-05-10 | 2024-05-10 | A1055 SS+120d | 23.91d | 0d | DIAS CALENDARIOS REV.03 |  |
| A1058 |  | FIN DE DIQUE MARGEN IZQUIERDA | milestone | 0d | 2024-05-10 | 2024-05-10 | A1054 SF+124d | 45.91d |  | DIAS CALENDARIOS REV.03 |  |
| A1057 |  | INICIO DE DIQUE INTERFERENCIA QUAVI | milestone | 0d | 2024-05-15 | 2024-05-15 | A1056 SS+5d | 33.91d | 0d | DIAS CALENDARIOS REV.03 |  |
| A1062 |  | FIN DE DIQUE INTERFERENCIA QUAVI | milestone | 0d | 2024-05-22 | 2024-05-22 | A1057 SF+8d | 33.91d |  | DIAS CALENDARIOS REV.03 |  |
| A1061 |  | FIN DE DIQUE LIBERACIÓN PREDIAL LD | milestone | 0d | 2024-06-01 | 2024-06-01 | A1056 SF+23d | 23.91d |  | DIAS CALENDARIOS REV.03 |  |
| A1080 |  | FIN DE PLAZO CONTRACTUAL-CULMINACIÓN DE OBRA | milestone | 0d | 2024-06-25 | 2024-06-25 | 01.10.03 FF, A1058 FF, A1059 FF, A1061 FF, A1062 FF | 0d |  | DIAS CALENDARIOS REV.03 |  |
|  | 3 | **CONSTRUCCIÓN SUB PROYECTO A1-RÍO LACRAMARCA** |  |  | 2023-12-19 | 2024-06-25 |  |  |  |  |  |
|  | 1 | **SUBPROYECTO A1 (OPCIÓN A)** |  |  | 2023-12-19 | 2024-06-21 |  |  |  |  |  |
|  | 1 | **DEFENSAS RIBEREÑAS** |  |  | 2023-12-19 | 2024-06-21 |  |  |  |  |  |
|  | 1 | **OBRAS PRELIMINARES** |  |  | 2023-12-19 | 2024-06-15 |  |  |  |  |  |
| 1.01.02 |  | INSTALACIONES PROVISIONALES PARA LA OBRA |  | 4d | 2023-12-19 | 2023-12-22 | A1030 SS | 132.8d | 0d |  | Camión grua; CAPATAZ; OPERARIO; PEON |
| 1.01.03 |  | MANTENIMIENTO DE TRÁNSITO Y SEGURIDAD VIAL |  | 149.5d | 2023-12-19 | 2024-06-15 | A1030 SS | 8.3d |  |  | Camión Cisterna 4x2 400 HP Agua (5000 gal); CAPATAZ; CUADRADOR/VIGÍA; Motoniveladora 185 HP; Retroexcavador 58 HP; Rodillo Vib. Liso Autopropulsado 135 HP 12 TM |
|  | 2 | **TRABAJOS PRELIMINARES** |  |  | 2023-12-19 | 2024-06-15 |  |  |  |  |  |
| 01.02.02 |  | TOPOGRAFÍA Y GEOREFERENCIACIÓN |  | 149.5d | 2023-12-19 | 2024-06-15 | A1030 SS | 8.3d |  |  | AYUDANTE DE NIVELADOR; AYUDANTE DE TOPOGRAFO; TOPOGRAFO; OP. NIVELADOR |

| ID | WBS | Activity | Duration | Start | Finish | Predecessors | Total float | Free float | Resources |
| --- | --- | --- | --- | --- | --- | --- | --- | --- | --- |
|  | 3 | **DIQUES DE TIERRA COMPACTADA CON ENROCADO** |  | 2024-02-05 | 2024-06-21 |  |  |  |  |
|  | 2 | **DIQUE DE TIERRA COMPACTADA A1-I-02** |  | 2024-02-05 | 2024-02-08 |  |  |  |  |
| 1.03.03 |  | COLOCACION Y ACOMODO DE ROCA EN UÑA DE DIQUE | 4d | 2024-02-05 | 2024-02-08 | 1.07.630 FS-1d | 110.8d | 0d | CAPATAZ; OPERARIO; PEON; Excavadora Sobre Oruga 260 HP |
| 1.03.04 |  | COLOCACION Y ACOMODO DE ROCA EN TALUD DE DIQUE | 3d | 2024-02-06 | 2024-02-08 | 1.03.03 FS-3d | 110.8d | 0d | CAPATAZ; PEON; Excavadora Sobre Oruga 260 HP; OPERARIO |
|  | 4 | **DIQUE DE TIERRA COMPACTADA A1-I-01** |  | 2024-03-30 | 2024-05-04 |  |  |  |  |
| 1.03.07 |  | COLOCACION Y ACOMODO DE ROCA EN UÑA DE DIQUE | 21.5d | 2024-03-30 | 2024-04-24 | 1.07.632 FS-5d | 21d | 0d | CAPATAZ; OPERARIO; PEON; Excavadora Sobre Oruga 260 HP |
| 1.03.08 |  | COLOCACION Y ACOMODO DE ROCA EN TALUD DE DIQUE | 16.5d | 2024-04-15 | 2024-05-04 | 1.03.07 FS-8.5d | 21d | 0d | CAPATAZ; PEON; Excavadora Sobre Oruga 260 HP; OPERARIO |
|  | 1 | **DIQUE DE TIERRA COMPACTADA A1-D-02** |  | 2024-02-07 | 2024-02-10 |  |  |  |  |
| 1.03.01 |  | COLOCACION Y ACOMODO DE ROCA EN UÑA DE DIQUE | 4d | 2024-02-07 | 2024-02-10 | 1.07.634 FS-1d | 110.8d | 0d | CAPATAZ; OPERARIO; PEON; Excavadora Sobre Oruga 260 HP |
| 1.03.02 |  | COLOCACION Y ACOMODO DE ROCA EN TALUD DE DIQUE | 3d | 2024-02-08 | 2024-02-10 | 1.03.01 FS-3d | 110.8d | 0d | CAPATAZ; PEON; Excavadora Sobre Oruga 260 HP; OPERARIO |
|  | 3 | **DIQUE DE TIERRA COMPACTADA A1-D-01** |  | 2024-04-05 | 2024-05-02 |  |  |  |  |
| 1.03.05 |  | COLOCACION Y ACOMODO DE ROCA EN UÑA DE DIQUE | 18.5d | 2024-04-05 | 2024-04-26 | 1.07.636 FS-2.4d | 0d |  | CAPATAZ; OPERARIO; PEON; Excavadora Sobre Oruga 260 HP |
| 1.03.06 |  | COLOCACION Y ACOMODO DE ROCA EN TALUD DE DIQUE | 12.5d | 2024-04-17 | 2024-05-02 | 1.03.05 FS-8.4d | 0d |  | CAPATAZ; PEON; Excavadora Sobre Oruga 260 HP; OPERARIO |
|  | 5 | **DIQUE DE TIERRA COMPACTADA LIBERACIÓN PREDIAL LD** |  | 2024-05-25 | 2024-06-01 |  |  |  |  |
| 1.03.15 |  | COLOCACION Y ACOMODO DE ROCA EN UÑA DE DIQUE | 1.5d | 2024-05-25 | 2024-05-27 | 1.07.779 FS+0.5d | 20.2d | 0d | CAPATAZ; OPERARIO; PEON; Excavadora Sobre Oruga 260 HP |
| 1.03.18 |  | COLOCACION Y ACOMODO DE ROCA EN TALUD DE DIQUE | 1.5d | 2024-05-30 | 2024-06-01 | 1.03.15 FS+3d | 20.2d | 0d | CAPATAZ; PEON; Excavadora Sobre Oruga 260 HP; OPERARIO |
|  | 6 | **DIQUE DE TIERRA COMPACTADA INTERFERENCIA QUAVI** |  | 2024-06-12 | 2024-06-21 |  |  |  |  |
| 1.03.28 |  | COLOCACION Y ACOMODO DE ROCA EN UÑA DE DIQUE | 4.5d | 2024-06-12 | 2024-06-17 | 1.07.789 FS+0.6d | 0d |  | CAPATAZ; OPERARIO; PEON; Excavadora Sobre Oruga 260 HP |
| 1.03.38 |  | COLOCACION Y ACOMODO DE ROCA EN TALUD DE DIQUE | 3.5d | 2024-06-18 | 2024-06-21 | 1.03.28 FS+0.5d | 0d |  | CAPATAZ; PEON; Excavadora Sobre Oruga 260 HP; OPERARIO |
|  | 8 | **OBRAS DE ARTE (REBOSES)** |  | 2024-02-03 | 2024-03-06 |  |  |  |  |
|  | 1 | **ESTRUCTURA DE REBOSE** |  | 2024-02-03 | 2024-03-06 |  |  |  |  |
|  | 1 | **OBRAS DE CONCRETO** |  | 2024-02-14 | 2024-03-06 |  |  |  |  |
| 1.04.01 |  | CONCRETO f'c=100 kg/cm2 | 1d | 2024-02-14 | 2024-02-14 | 1.08.04 | 91.8d | 0d | CAPATAZ; OPERARIO; PEON; OFICIAL |
| 1.04.04 |  | ACERO DE REFUERZO fy=4200 kg/cm2 | 12d | 2024-02-16 | 2024-02-29 | 1.04.01 FS+1d | 91.8d | 0d | CAPATAZ; OPERARIO; PEON |
| 1.04.03 |  | ENCOFRADO Y DESENCOFRADO RECTO | 14d | 2024-02-17 | 2024-03-04 | 1.04.04 SS+1d | 91.8d | 0d | CAPATAZ; OPERARIO; PEON |
| 1.04.02 |  | CONCRETO f'c=280 kg/cm2 | 2d | 2024-03-05 | 2024-03-06 | 1.04.03 | 91.8d |  | CAPATAZ; OPERARIO; PEON; OFICIAL |

| ID | WBS | Activity | Duration | Start | Finish | Predecessors | Total float | Free float | Resources |
| --- | --- | --- | --- | --- | --- | --- | --- | --- | --- |
|  | 2 | **TUBERÍAS** |  | 2024-02-03 | 2024-02-05 |  |  |  |  |
| 1.04.05 |  | SUMINISTRO E INSTALACIÓN DE TUBERÍA HDPE DN800 mm | 1d | 2024-02-03 | 2024-02-03 | 1.08.03 | 91.8d | 0d | CAPATAZ; OPERARIO; PEON; Retroexcavador 58 HP |
| 1.04.06 |  | SUMINISTRO E INSTALACIÓN DE TUBERÍA HDPE DN1000 mm | 1d | 2024-02-05 | 2024-02-05 | 1.04.05 | 91.8d | 0d | CAPATAZ; OPERARIO; PEON; Retroexcavador 58 HP |
|  | 9 | **INTERFERENCIAS** |  | 2023-12-23 | 2024-05-31 |  |  |  |  |
|  | 1 | **CANAL A REPONER DE SECCIÓN RECTANGULAR** |  | 2024-05-02 | 2024-05-31 |  |  |  |  |
|  | 1 | **OBRAS DE CONCRETO** |  | 2024-05-02 | 2024-05-31 |  |  |  |  |
| 1.04.09 |  | CONCRETO f'c=100 kg/cm2 | 0.5d | 2024-05-02 | 2024-05-02 | 1.09.04 FS-1.5d | 21d | 0d | CAPATAZ; OPERARIO; PEON; OFICIAL |
| 1.04.08 |  | ACERO DE REFUERZO fy=4200 kg/cm2 | 7.5d | 2024-05-03 | 2024-05-11 | 1.04.09 FS+0.5d | 21d | 0d | CAPATAZ; OPERARIO; PEON |
| 1.04.07 |  | ENCOFRADO Y DESENCOFRADO RECTO | 19.5d | 2024-05-04 | 2024-05-28 | 1.04.08 SS+1.1d | 21d | 0d | CAPATAZ; OPERARIO; PEON |
| 1.04.10 |  | CONCRETO f'c=280 kg/cm2 | 2.5d | 2024-05-28 | 2024-05-31 | 1.04.07 FS+0.5d | 21d | 0d | CAPATAZ; OPERARIO; PEON; OFICIAL |
| 1.04.11 |  | SELLO DE JUNTAS CON WATER STOP 6" | 2.5d | 2024-05-28 | 2024-05-31 | 1.04.10 SS | 21.9d |  | OPERARIO; PEON |
|  | 2 | **CANAL A REPONER DE SECCION TRAPEZOIDAL** |  | 2024-05-09 | 2024-05-22 |  |  |  |  |
|  | 1 | **OBRAS DE CONCRETO** |  | 2024-05-09 | 2024-05-22 |  |  |  |  |
| 1.04.12 |  | ENCOFRADO Y DESENCOFRADO RECTO | 8.5d | 2024-05-09 | 2024-05-18 | 1.09.08 FS-1.5d | 28.2d | 0d | CAPATAZ; OPERARIO; PEON |
| 1.04.15 |  | SELLO DE JUNTAS CON MATERIAL ELASTOMÉRICO | 5.5d | 2024-05-16 | 2024-05-22 | 1.04.14 SS-2.4d | 28.2d | 0d | CAPATAZ; OFICIAL; PEON |
| 1.04.13 |  | ENCOFRADO Y DESENCOFRADO CERCHAS DE MADERA | 1.5d | 2024-05-17 | 2024-05-18 | 1.04.12 FS-1.5d | 28.2d | 0d | CAPATAZ; OPERARIO; PEON |
| 1.04.14 |  | CONCRETO f'c=280 kg/cm2 | 2.5d | 2024-05-18 | 2024-05-22 | 1.04.13 | 28.2d | 0d | CAPATAZ; OPERARIO; PEON; OFICIAL |
|  | 3 | **AFECTACIÓN A ESTRUCTURAS PRIVADAS** |  | 2023-12-23 | 2024-01-18 |  |  |  |  |
|  | 1 | **MOVIMIENTO DE TIERRAS** |  | 2023-12-23 | 2024-01-11 |  |  |  |  |
| 1.04.16 |  | DEMOLICIÓN DE ESTRUCTURAS EXISTENTES | 8d | 2023-12-23 | 2024-01-03 | 1.01.02 | 132.8d | 0d | CAPATAZ; OPERARIO; PEON; Excavadora + Martillo hidraúlico |
| 1.04.17 |  | ELIMINACIÓN DE PRODUCTOS DE DEMOLICIÓN DE OBRAS DE CONCRETO | 14d | 2023-12-26 | 2024-01-11 | 1.04.16 FS-7d | 132.8d | 0d | CAPATAZ; OPERARIO; PEON; Excavadora + Martillo hidraúlico |
|  | 2 | **REPOSICIÓN DE TUBERÍAS DE PASO** |  | 2024-01-13 | 2024-01-16 |  |  |  |  |
| 1.04.18 |  | REPOSICIÓN DE TUBERÍAS DE HDPE DE 4" | 1d | 2024-01-13 | 2024-01-13 | 1.04.17 FS+1d | 132.8d | 0d | CAPATAZ; OPERARIO; PEON; Retroexcavador 58 HP |
| 1.04.19 |  | REPOSICIÓN DE TUBERÍAS DE HDPE DE 6" | 1d | 2024-01-15 | 2024-01-15 | 1.04.18 | 132.8d | 0d | CAPATAZ; OPERARIO; PEON; Retroexcavador 58 HP |
| 1.04.20 |  | REPOSICIÓN DE TUBERÍAS DE HDPE DE 8" | 1d | 2024-01-16 | 2024-01-16 | 1.04.19 | 132.8d | 0d | CAPATAZ; OPERARIO; PEON; Retroexcavador 58 HP |

| ID | WBS | Activity | Duration | Start | Finish | Predecessors | Total float | Free float | Resources |
| --- | --- | --- | --- | --- | --- | --- | --- | --- | --- |
|  | 3 | **REUBICACIÓN DE INTERFERENCIAS** |  | 2024-01-17 | 2024-01-18 |  |  |  |  |
| 1.04.21 |  | DEMOLICIÓN DE INTERFERENCIAS SIMA | 1d | 2024-01-17 | 2024-01-17 | 1.04.20 | 132.8d | 0d | CAPATAZ; OPERARIO; PEON; Excavadora + Martillo hidraúlico |
| 1.04.22 |  | ELIMINACIÓN DE INTERFERENCIAS SIMA | 1d | 2024-01-18 | 2024-01-18 | 1.04.21 | 132.8d |  | CAPATAZ; OPERARIO; PEON; Excavadora + Martillo hidraúlico |
|  | 2 | **SUBPROYECTO A1 (OPCIÓN B)** |  | 2023-12-19 | 2024-06-25 |  |  |  |  |
|  | 1 | **DEFENSAS RIBEREÑAS** |  | 2023-12-19 | 2024-06-22 |  |  |  |  |
|  | 1 | **MEJORAMIENTO DE VÍAS EXISTENTES** |  | 2023-12-19 | 2023-12-26 |  |  |  |  |
| 1.06.01 |  | REHABILITACIÓN DE VÍAS EXISTENTES | 6d | 2023-12-19 | 2023-12-26 | A1030 SS | 151.8d |  | CAPATAZ; CUADRADOR/VIGÍA; Tractor S/Orugas (D6T) - 180 HP; Camión Cisterna 4x2 400 HP Agua (5000 gal); OPERARIO; Excavadora Sobre Oruga 260 HP; Motoniveladora 185 HP; Rodillo Vib. Liso Autopropulsado 135 HP 12 TM |
|  | 2 | **DESCOLMATACIÓN DE CAUCE** |  | 2023-12-29 | 2024-02-29 |  |  |  |  |
| 1.07.01 |  | DESBROCE Y LIMPIEZA EN ZONA NO BOSCOSA - MARGEN IZQUIERDA | 7d | 2023-12-29 | 2024-01-06 | A1030 SS+10d | 91.8d | 0d | Camión Volquete (15 m3); Excavadora Sobre Oruga 260 HP; OPERARIO; PEON; Tractor S/Orugas (D6T) - 180 HP |
| 1.07.03 |  | DESCOLMATACIÓN DE CAUCE NATURAL DEL RÍO LACRAMARCA PROG: KM 03+300 A KM 01+650 | 21d | 2023-12-29 | 2024-01-23 | A1030 SS+10d | 2.3d | 0d | CUADRADOR/VIGÍA; Excavadora Sobre Oruga 260 HP; PEON; Tractor S/Orugas (D6T) - 180 HP; CAPATAZ |
| 1.07.02 |  | DESBROCE Y LIMPIEZA EN ZONA NO BOSCOSA - MARGEN DERECHA | 14d | 2024-01-08 | 2024-01-23 | 1.07.01 | 91.8d | 0d | Camión Volquete (15 m3); Excavadora Sobre Oruga 260 HP; OPERARIO; PEON; Tractor S/Orugas (D6T) - 180 HP |
| 1.07.04 |  | DESCOLMATACIÓN DE CAUCE NATURAL DEL RÍO LACRAMARCA PROG: KM 01+650 A KM 00+000 | 21d | 2024-01-25 | 2024-02-17 | 1.07.03 FS+1d | 96.8d | 0d | CUADRADOR/VIGÍA; Excavadora Sobre Oruga 260 HP; PEON; Tractor S/Orugas (D6T) - 180 HP; CAPATAZ |
| 1.07.05 |  | CONFORMACIÓN DE DESVIO EN CAUCE DE RÍO | 18d | 2024-02-09 | 2024-02-29 | 1.07.04 FS-8d | 96.8d |  | CAPATAZ; CUADRADOR/VIGÍA; Excavadora Sobre Oruga 260 HP; OPERARIO; Tractor S/Orugas (D6T) - 180 HP |
|  | 3 | **DIQUES DE TIERRA COMPACTADA CON ENROCADO** |  | 2024-01-08 | 2024-06-22 |  |  |  |  |
|  | 1 | **EXCAVACIÓN EN TERRENO NATURAL CON EQUIPO** |  | 2024-01-08 | 2024-05-21 |  |  |  |  |
| 1.07.110 |  | EXCAVACIÓN EN TERRENO NATURAL CON EQUIPO A1-I-02 | 6d | 2024-01-08 | 2024-01-13 | A1040 SS | 0d |  | CAPATAZ; PEON; Tractor S/Orugas (D6T) - 180 HP; Excavadora Sobre Oruga 260 HP |
| 1.07.112 |  | EXCAVACIÓN EN TERRENO NATURAL CON EQUIPO A1-I-01 | 31d | 2024-01-11 | 2024-02-15 | 1.07.110 FS-3d | 0d |  | CAPATAZ; PEON; Tractor S/Orugas (D6T) - 180 HP; Excavadora Sobre Oruga 260 HP |
| 1.07.114 |  | EXCAVACIÓN EN TERRENO NATURAL CON EQUIPO A1-D-02 | 5d | 2024-01-11 | 2024-01-16 | 1.07.112 SS | 0d |  | CAPATAZ; PEON; Tractor S/Orugas (D6T) - 180 HP; Excavadora Sobre Oruga 260 HP |
| 1.07.119.1 |  | EXCAVACIÓN EN TERRENO NATURAL CON EQUIPO RAMPAS | 1d | 2024-01-17 | 2024-01-17 | 1.07.114 | 20.2d | 0d | CAPATAZ; PEON; Tractor S/Orugas (D6T) - 180 HP; Excavadora Sobre Oruga 260 HP |
| 1.07.116 |  | EXCAVACIÓN EN TERRENO NATURAL CON EQUIPO A1-D-01 | 23d | 2024-01-22 | 2024-02-16 | 1.07.114 FS+4d | 0d |  | CAPATAZ; PEON; Tractor S/Orugas (D6T) - 180 HP; Excavadora Sobre Oruga 260 HP |
| 1.07.117 |  | EXCAVACIÓN EN TERRENO NATURAL LIBERACIÓN PREDIAL LD | 2.5d | 2024-05-10 | 2024-05-13 | 1.07.646 FS+0.5d | 0d |  | CAPATAZ; PEON; Tractor S/Orugas (D6T) - 180 HP; Excavadora Sobre Oruga 260 HP |
| 1.07.119 |  | EXCAVACIÓN EN TERRENO NATURAL INTERFERENCIA QUAVI | 5.5d | 2024-05-15 | 2024-05-21 | 1.07.117 FS+1.5d | 0d |  | CAPATAZ; PEON; Tractor S/Orugas (D6T) - 180 HP; Excavadora Sobre Oruga 260 HP |
|  | 2 | **EXCAVACIÓN DE UÑA CON EQUIPO** |  | 2024-01-12 | 2024-05-21 |  |  |  |  |
| 1.07.120 |  | EXCAVACIÓN DE UÑA CON EQUIPO A1-I-02 | 2d | 2024-01-12 | 2024-01-13 | 1.07.110 FS-2d | 6.3d | 0d | CAPATAZ; Excavadora Sobre Oruga 260 HP; PEON |
| 1.07.124 |  | EXCAVACIÓN DE UÑA CON EQUIPO A1-D-02 | 2d | 2024-01-15 | 2024-01-16 | 1.07.114 FS-2d | 110.8d | 0d | CAPATAZ; Excavadora Sobre Oruga 260 HP; PEON |
| 1.07.122 |  | EXCAVACIÓN DE UÑA CON EQUIPO A1-I-01 | 10d | 2024-02-05 | 2024-02-15 | 1.07.112 FS-10d | 21d | 0d | CAPATAZ; Excavadora Sobre Oruga 260 HP; PEON |
| 1.07.126 |  | EXCAVACIÓN DE UÑA CON EQUIPO A1-D-01 | 8d | 2024-02-08 | 2024-02-16 | 1.07.116 FS-8d | 0d |  | CAPATAZ; Excavadora Sobre Oruga 260 HP; PEON |
| 1.07.658 |  | EXCAVACIÓN DE UÑA CON EQUIPO LIBERACIÓN PREDIAL LD | 0.5d | 2024-05-13 | 2024-05-13 | 1.07.117 FS-0.5d | 20.2d | 0d | CAPATAZ; Excavadora Sobre Oruga 260 HP; PEON |
| 1.07.668 |  | EXCAVACIÓN DE UÑA CON EQUIPO INTERFERENCIA QUAVI | 1.5d | 2024-05-20 | 2024-05-21 | 1.07.119 FS-1.5d | 0d |  | CAPATAZ; Excavadora Sobre Oruga 260 HP; PEON |

| ID | WBS | Activity | Duration | Start | Finish | Predecessors | Total float | Free float | Resources |
| --- | --- | --- | --- | --- | --- | --- | --- | --- | --- |
|  | 3 | **PERFILADO Y COMPACTACIÓN EN ZONA DE CORTE** |  | 2024-01-15 | 2024-05-24 |  |  |  |  |
| 1.07.130 |  | PERFILADO Y COMPACTACIÓN EN ZONA DE CORTE A1-I-02 | 2d | 2024-01-15 | 2024-01-16 | 1.07.120 | 6.3d | 0d | CAPATAZ; Excavadora Sobre Oruga 260 HP; PEON; Rodillo Vib. Liso Autopropulsado 135 HP 12 TM; Motoniveladora 185 HP; Camión Cisterna 4x2 400 HP Agua (5000 gal) |
| 1.07.134 |  | PERFILADO Y COMPACTACIÓN EN ZONA DE CORTE A1-D-02 | 2d | 2024-01-17 | 2024-01-18 | 1.07.124 | 110.8d | 0d | CAPATAZ; Excavadora Sobre Oruga 260 HP; PEON; Rodillo Vib. Liso Autopropulsado 135 HP 12 TM; Motoniveladora 185 HP; Camión Cisterna 4x2 400 HP Agua (5000 gal) |
| 1.07.132 |  | PERFILADO Y COMPACTACIÓN EN ZONA DE CORTE A1-I-01 | 12d | 2024-02-10 | 2024-02-23 | 1.07.122 FS-5d | 21d | 0d | CAPATAZ; Excavadora Sobre Oruga 260 HP; PEON; Rodillo Vib. Liso Autopropulsado 135 HP 12 TM; Motoniveladora 185 HP; Camión Cisterna 4x2 400 HP Agua (5000 gal) |
| 1.07.136 |  | PERFILADO Y COMPACTACIÓN EN ZONA DE CORTE A1-D-01 | 9d | 2024-02-14 | 2024-02-23 | 1.07.126 FS-3d | 0d |  | CAPATAZ; Excavadora Sobre Oruga 260 HP; PEON; Rodillo Vib. Liso Autopropulsado 135 HP 12 TM; Motoniveladora 185 HP; Camión Cisterna 4x2 400 HP Agua (5000 gal) |
| 1.07.678 |  | PERFILADO Y COMPACTACIÓN EN ZONA DE CORTE LIBERACIÓN PREDIAL LD | 0.5d | 2024-05-15 | 2024-05-15 | 1.07.658 FS+1.5d | 20.2d | 0d | CAPATAZ; Excavadora Sobre Oruga 260 HP; PEON; Rodillo Vib. Liso Autopropulsado 135 HP 12 TM; Motoniveladora 185 HP; Camión Cisterna 4x2 400 HP Agua (5000 gal) |
| 1.07.688 |  | PERFILADO Y COMPACTACIÓN EN ZONA DE CORTE INTERFERENCIA QUAVI | 1.5d | 2024-05-23 | 2024-05-24 | 1.07.668 FS+1.5d | 0d |  | CAPATAZ; Excavadora Sobre Oruga 260 HP; PEON; Rodillo Vib. Liso Autopropulsado 135 HP 12 TM; Motoniveladora 185 HP; Camión Cisterna 4x2 400 HP Agua (5000 gal) |
|  | 4 | **PEDRAPLÉN e=60 cm** |  | 2024-01-17 | 2024-05-28 |  |  |  |  |
| 1.07.410 |  | PEDRAPLÉN e=60 cm A1-I-02 | 4d | 2024-01-17 | 2024-01-20 | 1.07.130, A1050 SF | 6.3d | 0d | CAPATAZ; OPERARIO; PEON; OFICIAL; CARGADOR SOBRE LLANTAS DE 200-250 HP; Excavadora Sobre Oruga 320 |
| 1.07.414 |  | PEDRAPLÉN e=60 cm A1-D-02 | 4d | 2024-01-19 | 2024-01-23 | 1.07.134 | 110.8d | 0d | CAPATAZ; OPERARIO; PEON; OFICIAL; CARGADOR SOBRE LLANTAS DE 200-250 HP; Excavadora Sobre Oruga 320 |
| 1.07.416 |  | PEDRAPLÉN e=60 cm A1-D-01 | 12d | 2024-02-19 | 2024-03-02 | 1.07.136 FS-5d | 0d |  | CAPATAZ; OPERARIO; PEON; OFICIAL; CARGADOR SOBRE LLANTAS DE 200-250 HP; Excavadora Sobre Oruga 320 |
| 1.07.412 |  | PEDRAPLÉN e=60 cm A1-I-01 | 14d | 2024-02-20 | 2024-03-06 | 1.07.132 FS-4d | 21d | 0d | CAPATAZ; OPERARIO; PEON; OFICIAL; CARGADOR SOBRE LLANTAS DE 200-250 HP; Excavadora Sobre Oruga 320 |
| 1.07.698 |  | PEDRAPLÉN e=60 cm LIBERACIÓN PREDIAL LD | 1.5d | 2024-05-16 | 2024-05-17 | 1.07.678 FS+0.5d | 20.2d | 0d | CAPATAZ; OPERARIO; PEON; OFICIAL; CARGADOR SOBRE LLANTAS DE 200-250 HP; Excavadora Sobre Oruga 320 |
| 1.07.708 |  | PEDRAPLÉN e=60 cm INTERFERENCIA QUAVI | 2.5d | 2024-05-25 | 2024-05-28 | 1.07.688 FS+0.5d | 0d |  | CAPATAZ; OPERARIO; PEON; OFICIAL; CARGADOR SOBRE LLANTAS DE 200-250 HP; Excavadora Sobre Oruga 320 |
|  | 5 | **PEDRAPLÉN e=30 cm** |  | 2024-01-22 | 2024-05-30 |  |  |  |  |
| 1.07.510 |  | PEDRAPLÉN e=30 cm A1-I-02 | 2d | 2024-01-22 | 2024-01-23 | 1.07.410 | 110.8d | 0d | CAPATAZ; Motoniveladora 185 HP; OPERARIO; PEON; OFICIAL; CARGADOR SOBRE LLANTAS DE 200-250 HP; Excavadora Sobre Oruga 320 |
| 1.07.514 |  | PEDRAPLÉN e=30 cm A1-D-02 | 2d | 2024-01-24 | 2024-01-25 | 1.07.414 | 110.8d | 0d | CAPATAZ; Motoniveladora 185 HP; OPERARIO; PEON; OFICIAL; CARGADOR SOBRE LLANTAS DE 200-250 HP; Excavadora Sobre Oruga 320 |
| 1.07.512 |  | PEDRAPLÉN e=30 cm A1-I-01 | 10d | 2024-02-27 | 2024-03-08 | 1.07.412 FS-8d | 21d | 0d | CAPATAZ; Motoniveladora 185 HP; OPERARIO; PEON; OFICIAL; CARGADOR SOBRE LLANTAS DE 200-250 HP; Excavadora Sobre Oruga 320 |
| 1.07.516 |  | PEDRAPLÉN e=30 cm A1-D-01 | 9d | 2024-02-27 | 2024-03-07 | 1.07.416 FS-5d | 0d |  | CAPATAZ; Motoniveladora 185 HP; OPERARIO; PEON; OFICIAL; CARGADOR SOBRE LLANTAS DE 200-250 HP; Excavadora Sobre Oruga 320 |
| 1.07.718 |  | PEDRAPLÉN e=30 cm LIBERACIÓN PREDIAL LD | 0.5d | 2024-05-18 | 2024-05-18 | 1.07.698 FS+0.5d | 20.2d | 0d | CAPATAZ; Motoniveladora 185 HP; OPERARIO; PEON; OFICIAL; CARGADOR SOBRE LLANTAS DE 200-250 HP; Excavadora Sobre Oruga 320 |
| 1.07.728 |  | PEDRAPLÉN e=30 cm INTERFERENCIA QUAVI | 1.5d | 2024-05-29 | 2024-05-30 | 1.07.708 FS+0.5d | 0d |  | CAPATAZ; Motoniveladora 185 HP; OPERARIO; PEON; OFICIAL; CARGADOR SOBRE LLANTAS DE 200-250 HP; Excavadora Sobre Oruga 320 |
|  | 6 | **CONFORMACIÓN DE CUERPO DE DIQUE CON MATERIAL DE PRÉSTAMO** |  | 2024-01-19 | 2024-06-04 |  |  |  |  |
| 1.07.749 |  | CONFORMACIÓN DE CUERPO DE RAMPA CON MATERIAL DE PRESTAMO | 1d | 2024-01-19 | 2024-01-19 | 1.07.119.1 FS+1d | 20.2d | 0d | Camión Cisterna 4x2 400 HP Agua (5000 gal); CAPATAZ; Motoniveladora 185 HP; OPERARIO; PEON; Rodillo Vib. Liso Autopropulsado 135 HP 12 TM; OFICIAL; Excavadora Sobre Oruga 260 HP; CARGADOR SOBRE LLANTAS DE 200-250 HP |
| 1.07.610 |  | CONFORMACIÓN DE CUERPO DE DIQUE CON MATERIAL DE PRÉSTAMO A1-I-02 | 5d | 2024-01-25 | 2024-01-30 | 1.07.510 FS+1d | 110.8d | 0d | Camión Cisterna 4x2 400 HP Agua (5000 gal); CAPATAZ; Motoniveladora 185 HP; OPERARIO; PEON; Rodillo Vib. Liso Autopropulsado 135 HP 12 TM; OFICIAL; Excavadora Sobre Oruga 260 HP; CARGADOR SOBRE LLANTAS DE 200-250 HP |
| 1.07.614 |  | CONFORMACIÓN DE CUERPO DE DIQUE CON MATERIAL DE PRÉSTAMO A1-D-02 | 5d | 2024-01-27 | 2024-02-01 | 1.07.514 FS+1d | 110.8d | 0d | Camión Cisterna 4x2 400 HP Agua (5000 gal); CAPATAZ; Motoniveladora 185 HP; OPERARIO; PEON; Rodillo Vib. Liso Autopropulsado 135 HP 12 TM; OFICIAL; Excavadora Sobre Oruga 260 HP; CARGADOR SOBRE LLANTAS DE 200-250 HP |
| 1.07.616 |  | CONFORMACIÓN DE CUERPO DE DIQUE CON MATERIAL DE PRÉSTAMO A1-D-01 | 17d | 2024-03-01 | 2024-03-20 | 1.07.516 FS-6d | 0d |  | Camión Cisterna 4x2 400 HP Agua (5000 gal); CAPATAZ; Motoniveladora 185 HP; OPERARIO; PEON; Rodillo Vib. Liso Autopropulsado 135 HP 12 TM; OFICIAL; Excavadora Sobre Oruga 260 HP; CARGADOR SOBRE LLANTAS DE 200-250 HP |
| 1.07.612 |  | CONFORMACIÓN DE CUERPO DE DIQUE CON MATERIAL DE PRÉSTAMO A1-I-01 | 19d | 2024-03-04 | 2024-03-25 | 1.07.512 FS-5d | 21d | 0d | Camión Cisterna 4x2 400 HP Agua (5000 gal); CAPATAZ; Motoniveladora 185 HP; OPERARIO; PEON; Rodillo Vib. Liso Autopropulsado 135 HP 12 TM; OFICIAL; Excavadora Sobre Oruga 260 HP; CARGADOR SOBRE LLANTAS DE 200-250 HP |
| 1.07.738 |  | CONFORMACIÓN DE CUERPO DE DIQUE CON MATERIAL DE PRÉSTAMO LIBERACIÓN PREDIAL LD | 1.5d | 2024-05-20 | 2024-05-21 | 1.07.718 FS+0.5d | 20.2d | 0d | Camión Cisterna 4x2 400 HP Agua (5000 gal); CAPATAZ; Motoniveladora 185 HP; OPERARIO; PEON; Rodillo Vib. Liso Autopropulsado 135 HP 12 TM; OFICIAL; Excavadora Sobre Oruga 260 HP; CARGADOR SOBRE LLANTAS DE 200-250 HP |
| 1.07.748 |  | CONFORMACIÓN DE CUERPO DE DIQUE CON MATERIAL DE PRÉSTAMO INTERFERENCIA QUAVI | 3.5d | 2024-05-31 | 2024-06-04 | 1.07.728 FS+0.5d | 0d |  | Camión Cisterna 4x2 400 HP Agua (5000 gal); CAPATAZ; Motoniveladora 185 HP; OPERARIO; PEON; Rodillo Vib. Liso Autopropulsado 135 HP 12 TM; OFICIAL; Excavadora Sobre Oruga 260 HP; CARGADOR SOBRE LLANTAS DE 200-250 HP |

| ID | WBS | Activity | Duration | Start | Finish | Predecessors | Total float | Free float | Resources |
| --- | --- | --- | --- | --- | --- | --- | --- | --- | --- |
|  | 7 | **CONFORMACIÓN DE RELLENO NO ESTRUCTURAL CON MATERIAL PROPIO** |  | 2024-01-31 | 2024-06-05 |  |  |  |  |
| 1.07.620 |  | CONFORMACIÓN DE RELLENO NO ESTRUCTURAL CON MATERIAL PROPIO A1-I-02 | 2d | 2024-01-31 | 2024-02-01 | 1.07.610 | 110.8d | 0d | Camión Cisterna 4x2 400 HP Agua (5000 gal); CAPATAZ; OPERARIO; PEON; Rodillo Vib. Liso Autopropulsado 135 HP 12 TM; Tractor S/Orugas (D6T) - 180 HP |
| 1.07.624 |  | CONFORMACIÓN DE RELLENO NO ESTRUCTURAL CON MATERIAL PROPIO A1-D-02 | 2d | 2024-02-02 | 2024-02-03 | 1.07.614 | 110.8d | 0d | Camión Cisterna 4x2 400 HP Agua (5000 gal); CAPATAZ; OPERARIO; PEON; Rodillo Vib. Liso Autopropulsado 135 HP 12 TM; Tractor S/Orugas (D6T) - 180 HP |
| 1.07.626 |  | CONFORMACIÓN DE RELLENO NO ESTRUCTURAL CON MATERIAL PROPIO A1-D-01 | 3d | 2024-03-19 | 2024-03-21 | 1.07.616 FS-2d | 0d |  | Camión Cisterna 4x2 400 HP Agua (5000 gal); CAPATAZ; OPERARIO; PEON; Rodillo Vib. Liso Autopropulsado 135 HP 12 TM; Tractor S/Orugas (D6T) - 180 HP |
| 1.07.622 |  | CONFORMACIÓN DE RELLENO NO ESTRUCTURAL CON MATERIAL PROPIO A1-I-01 | 5d | 2024-03-23 | 2024-03-30 | 1.07.612 FS-2d | 21d | 0d | Camión Cisterna 4x2 400 HP Agua (5000 gal); CAPATAZ; OPERARIO; PEON; Rodillo Vib. Liso Autopropulsado 135 HP 12 TM; Tractor S/Orugas (D6T) - 180 HP |
| 1.07.759 |  | CONFORMACIÓN DE RELLENO NO ESTRUCTURAL CON MATERIAL PROPIO LIBERACIÓN PREDIAL LD | 0.5d | 2024-05-22 | 2024-05-22 | 1.07.738 FS+0.5d | 20.2d | 0d | Camión Cisterna 4x2 400 HP Agua (5000 gal); CAPATAZ; OPERARIO; PEON; Rodillo Vib. Liso Autopropulsado 135 HP 12 TM; Tractor S/Orugas (D6T) - 180 HP |
| 1.07.769 |  | CONFORMACIÓN DE RELLENO NO ESTRUCTURAL CON MATERIAL PROPIO INTERFERENCIA QUAVI | 0.5d | 2024-06-05 | 2024-06-05 | 1.07.748 FS+0.4d | 0d |  | Camión Cisterna 4x2 400 HP Agua (5000 gal); CAPATAZ; OPERARIO; PEON; Rodillo Vib. Liso Autopropulsado 135 HP 12 TM; Tractor S/Orugas (D6T) - 180 HP |
|  | 8 | **GEOTEXTIL NO TEJIDO 400 G/M2, INC. COLOCACIÓN** |  | 2024-02-02 | 2024-06-11 |  |  |  |  |
| 1.07.630 |  | GEOTEXTIL NO TEJIDO 400 G/M2, INC. COLOCACIÓN A1-I-02 | 3d | 2024-02-02 | 2024-02-05 | 1.07.620 | 110.8d | 0d | CAPATAZ; OPERARIO; PEON |
| 1.07.634 |  | GEOTEXTIL NO TEJIDO 400 G/M2, INC. COLOCACIÓN A1-D-02 | 3d | 2024-02-05 | 2024-02-07 | 1.07.624 | 110.8d | 0d | CAPATAZ; OPERARIO; PEON |
| 1.07.632 |  | GEOTEXTIL NO TEJIDO 400 G/M2, INC. COLOCACIÓN A1-I-01 | 17d | 2024-03-14 | 2024-04-04 | 1.07.622 FS-13d | 21d | 0d | CAPATAZ; OPERARIO; PEON |
| 1.07.636 |  | GEOTEXTIL NO TEJIDO 400 G/M2, INC. COLOCACIÓN A1-D-01 | 13.5d | 2024-03-21 | 2024-04-08 | 1.07.626 FS-1d | 0d |  | CAPATAZ; OPERARIO; PEON |
| 1.07.779 |  | GEOTEXTIL NO TEJIDO 400 G/M2, INC. COLOCACIÓN LIBERACIÓN PREDIAL LD | 1.5d | 2024-05-23 | 2024-05-24 | 1.07.759 FS+0.5d | 20.2d | 0d | CAPATAZ; OPERARIO; PEON |
| 1.07.789 |  | GEOTEXTIL NO TEJIDO 400 G/M2, INC. COLOCACIÓN INTERFERENCIA QUAVI | 3.5d | 2024-06-07 | 2024-06-11 | 1.07.769 FS+1.5d | 0d |  | CAPATAZ; OPERARIO; PEON |
|  | 9 | **CONFORMACIÓN DE MATERIAL GRANULAR EN CORONA DE DIQUE** |  | 2024-01-20 | 2024-06-22 |  |  |  |  |
| 1.07.810 |  | CONFORMACIÓN DE MATERIAL GRANULAR EN CORONA | 1d | 2024-01-20 | 2024-01-20 | 1.07.749 | 130.8d |  | Camión Cisterna 4x2 400 HP Agua (5000 gal); CAPATAZ; Motoniveladora 185 HP; OPERARIO; PEON; Rodillo Vib. Liso Autopropulsado 135 HP 12 TM; OFICIAL; Excavadora Sobre Oruga 260 HP; CARGADOR SOBRE LLANTAS DE 200-250 HP |
| 1.07.640 |  | CONFORMACIÓN DE MATERIAL GRANULAR EN CORONA DE DIQUE A1-I-02 | 2.5d | 2024-02-10 | 2024-02-13 | 1.03.04 FS+1.5d | 110.8d |  | Camión Cisterna 4x2 400 HP Agua (5000 gal); CAPATAZ; Motoniveladora 185 HP; OPERARIO; PEON; Rodillo Vib. Liso Autopropulsado 135 HP 12 TM; OFICIAL; Excavadora Sobre Oruga 260 HP; CARGADOR SOBRE LLANTAS DE 200-250 HP |
| 1.07.644 |  | CONFORMACIÓN DE MATERIAL GRANULAR EN CORONA DE DIQUE A1-D-02 | 2d | 2024-02-12 | 2024-02-13 | 1.03.02 | 110.8d |  | Camión Cisterna 4x2 400 HP Agua (5000 gal); CAPATAZ; Motoniveladora 185 HP; OPERARIO; PEON; Rodillo Vib. Liso Autopropulsado 135 HP 12 TM; OFICIAL; Excavadora Sobre Oruga 260 HP; CARGADOR SOBRE LLANTAS DE 200-250 HP |
| 1.07.646 |  | CONFORMACIÓN DE MATERIAL GRANULAR EN CORONA DE DIQUE A1-D-01 | 4.5d | 2024-05-04 | 2024-05-09 | 1.03.06 FS+1.5d | 0d |  | Camión Cisterna 4x2 400 HP Agua (5000 gal); CAPATAZ; Motoniveladora 185 HP; OPERARIO; PEON; Rodillo Vib. Liso Autopropulsado 135 HP 12 TM; OFICIAL; Excavadora Sobre Oruga 260 HP; CARGADOR SOBRE LLANTAS DE 200-250 HP |
| 1.07.642 |  | CONFORMACIÓN DE MATERIAL GRANULAR EN CORONA DE DIQUE A1-I-01 | 4.5d | 2024-05-06 | 2024-05-10 | 1.03.08 FS+0.5d | 21d | 0d | Camión Cisterna 4x2 400 HP Agua (5000 gal); CAPATAZ; Motoniveladora 185 HP; OPERARIO; PEON; Rodillo Vib. Liso Autopropulsado 135 HP 12 TM; OFICIAL; Excavadora Sobre Oruga 260 HP; CARGADOR SOBRE LLANTAS DE 200-250 HP |
| 1.07.799 |  | CONFORMACIÓN DE MATERIAL GRANULAR EN CORONA DE DIQUE LIBERACIÓN PREDIAL LD | 0.5d | 2024-06-01 | 2024-06-01 | 1.03.18 FS-0.1d | 20.2d |  | Camión Cisterna 4x2 400 HP Agua (5000 gal); CAPATAZ; Motoniveladora 185 HP; OPERARIO; PEON; Rodillo Vib. Liso Autopropulsado 135 HP 12 TM; OFICIAL; Excavadora Sobre Oruga 260 HP; CARGADOR SOBRE LLANTAS DE 200-250 HP |
| 1.07.809 |  | CONFORMACIÓN DE MATERIAL GRANULAR EN CORONA DE DIQUE INTERFERENCIA QUAVI | 0.5d | 2024-06-22 | 2024-06-22 | 1.03.38 FS+0.5d | 0d |  | Camión Cisterna 4x2 400 HP Agua (5000 gal); CAPATAZ; Motoniveladora 185 HP; OPERARIO; PEON; Rodillo Vib. Liso Autopropulsado 135 HP 12 TM; OFICIAL; Excavadora Sobre Oruga 260 HP; CARGADOR SOBRE LLANTAS DE 200-250 HP |
|  | 4 | **OBRAS DE ARTE (REBOSES)** |  | 2024-01-25 | 2024-02-13 |  |  |  |  |
|  | 1 | **ESTRUCTURA DE REBOSE** |  | 2024-01-25 | 2024-02-13 |  |  |  |  |
|  | 1 | **MOVIMIENTO DE TIERRAS** |  | 2024-01-25 | 2024-02-13 |  |  |  |  |
| 1.08.01 |  | DESBROCE Y LIMPIEZA | 1d | 2024-01-25 | 2024-01-25 | 1.07.02 FS+1d | 91.8d | 0d | Camión Volquete (15 m3); Excavadora Sobre Oruga 260 HP; OPERARIO; PEON; Tractor S/Orugas (D6T) - 180 HP |
| 1.08.02 |  | EXCAVACIÓN ESTRUCTURAL BAJO AGUA | 3d | 2024-01-26 | 2024-01-29 | 1.08.01 | 91.8d | 0d | CAPATAZ; PEON; Tractor S/Orugas (D6T) - 180 HP; Excavadora Sobre Oruga 260 HP |
| 1.08.03 |  | CAMA DE ARENA | 4d | 2024-01-30 | 2024-02-02 | 1.08.02 | 91.8d | 0d | CAPATAZ; PEON |
| 1.08.04 |  | RELLENO ESTRUCTURAL PARA OBRAS DE ARTE CON MATERIAL DE PRÉSTAMO | 7d | 2024-02-06 | 2024-02-13 | 1.04.06 | 91.8d | 0d | Camión Cisterna 4x2 400 HP Agua (5000 gal); CAPATAZ; PEON; Rodillo Vib. Liso Autopropulsado 135 HP 12 TM; CUADRADOR/VIGÍA; CARGADOR SOBRE LLANTAS DE 200-250 HP |

| ID | WBS | Activity | Duration | Start | Finish | Predecessors | Total float | Free float | Resources |
| --- | --- | --- | --- | --- | --- | --- | --- | --- | --- |
|  | 5 | **TRANSPORTE DE MATERIAL** |  | 2024-01-13 | 2024-06-22 |  |  |  |  |
| 1.08.06 |  | TRANSPORTE DE ROCA | 131.5d | 2024-01-13 | 2024-06-18 | 1.07.410 FS-7d | 6.3d |  | CAPATAZ; CUADRADOR/VIGÍA; Excavadora Sobre Oruga 260 HP; Camión Volquete Roquero (15 m3) |
| 1.08.05 |  | TRANSPORTE DE MATERIAL GRANULAR | 116.5d | 2024-01-15 | 2024-06-01 | 1.07.749 SS-3.9d | 20.2d |  | CAPATAZ; Excavadora Sobre Oruga 260 HP; Camión Volquete (15 m3); CUADRADOR/VIGÍA |
| 1.08.07 |  | TRANSPORTE DE MATERIAL EXCEDENTE | 117.5d | 2024-02-03 | 2024-06-22 | 1.07.03 FS+9d | 2.3d |  | Camión Volquete (15 m3); CAPATAZ; CUADRADOR/VIGÍA; Excavadora Sobre Oruga 260 HP |
|  | 6 | **INTERFERENCIAS** |  | 2024-04-26 | 2024-05-31 |  |  |  |  |
|  | 1 | **CANAL A REPONER DE SECCIÓN RECTANGULAR** |  | 2024-04-26 | 2024-05-31 |  |  |  |  |
|  | 1 | **MOVIMIENTO DE TIERRAS** |  | 2024-04-26 | 2024-05-31 |  |  |  |  |
| 1.09.01 |  | DEMOLICION DE ESTRUCTURAS EXISTENTE | 3.5d | 2024-04-26 | 2024-04-30 | 1.07.642 FS-11.4d | 21d | 0d | CAPATAZ; OPERARIO; PEON; Excavadora + Martillo hidraúlico |
| 1.09.02 |  | EXCAVACIÓN EN TERRENO NATURAL CON EQUIPO | 1.5d | 2024-04-29 | 2024-04-30 | 1.09.01 FS-1.4d | 21d | 0d | CAPATAZ; PEON; Excavadora Sobre Oruga 260 HP; Tractor S/Orugas (D6T) - 180 HP |
| 1.09.04 |  | ELIMINACIÓN DE PRODUCTOS DE DEMOLICIÓN DE OBRAS DE CONCRETO | 2.5d | 2024-04-30 | 2024-05-03 | 1.09.02 SS+1.1d | 21d | 0d | CAPATAZ; OPERARIO; PEON; Camión Volquete (15 m3); Excavadora Sobre Oruga 260 HP |
| 1.09.03 |  | RELLENO ESTRUCTURAL PARA OBRAS DE ARTE CON MATERIAL DE PRÉSTAMO | 4.5d | 2024-05-27 | 2024-05-31 | 1.04.10 FS-3.6d | 21d |  | CAPATAZ; CUADRADOR/VIGÍA; PEON; Rodillo Vib. Liso Autopropulsado 135 HP 12 TM; Camión Cisterna 4x2 400 HP Agua (5000 gal); CARGADOR SOBRE LLANTAS DE 200-250 HP |
|  | 2 | **CANAL A REPONER DE SECCIÓN TRAPEZOIDAL** |  | 2024-05-02 | 2024-05-23 |  |  |  |  |
|  | 1 | **MOVIMIENTO DE TIERRAS** |  | 2024-05-02 | 2024-05-23 |  |  |  |  |
| 1.09.05 |  | DEMOLICION DE ESTRUCTURAS EXISTENTE | 3.5d | 2024-05-02 | 2024-05-06 | 1.09.01 FS+0.5d | 28.2d | 0d | CAPATAZ; OPERARIO; PEON; Excavadora + Martillo hidraúlico |
| 1.09.06 |  | EXCAVACIÓN EN TERRENO NATURAL CON EQUIPO | 1.5d | 2024-05-06 | 2024-05-08 | 1.09.05 | 28.2d | 0d | CAPATAZ; PEON; Excavadora Sobre Oruga 260 HP; Tractor S/Orugas (D6T) - 180 HP |
| 1.09.08 |  | ELIMINACIÓN DE PRODUCTOS DE DEMOLICIÓN DE OBRAS DE CONCRETO | 1.5d | 2024-05-09 | 2024-05-10 | 1.09.06 FS+0.9d | 28.2d | 0d | CAPATAZ; OPERARIO; PEON; Excavadora Sobre Oruga 260 HP; Camión Volquete (15 m3) |
| 1.09.07 |  | RELLENO ESTRUCTURAL PARA OBRAS DE ARTE CON MATERIAL DE PRÉSTAMO | 0.5d | 2024-05-23 | 2024-05-23 | 1.04.15 FS+0.5d | 28.2d |  | CAPATAZ; CUADRADOR/VIGÍA; PEON; Rodillo Vib. Liso Autopropulsado 135 HP 12 TM; Camión Cisterna 4x2 400 HP Agua (5000 gal); CARGADOR SOBRE LLANTAS DE 200-250 HP |
|  | 7 | **PROGRAMA DE CIERRE DE OBRA** |  | 2024-01-25 | 2024-06-25 |  |  |  |  |
| 01.10.01 |  | ACONDICIONAMIENTO DE DEPÓSITOS DE MATERIALES EXCEDENTES (DME) | 115.5d | 2024-01-25 | 2024-06-11 | 1.07.03 FS+1d | 12.3d |  | Camión Cisterna 4x2 400 HP Agua (5000 gal); CAPATAZ; OPERARIO; Tractor S/Orugas (D6T) - 180 HP |
| 01.10.02 |  | RESTAURACIÓN DE ÁREAS DE INSTALACIONES PROVISIONALES | 7.5d | 2024-06-15 | 2024-06-24 | 1.07.809 FS-6.4d | 0d |  | CAPATAZ; PEON; Camión Cisterna 4x2 400 HP Agua (5000 gal); Rodillo Vib. Liso Autopropulsado 135 HP 12 TM |
| 01.10.03 |  | DESMOVILIZACIÓN DE EQUIPOS | 7.5d | 2024-06-17 | 2024-06-25 | 01.10.02 FS-6.5d, 01.02.02 FF, 01.10.01 FF, 1.01.03 FF, 1.04.02 FF, 1.04.11 FF, 1.04.22 FF, 1.06.01 FF, 1.07.05 FF, 1.07.640 FF, 1.07.644 FF, 1.07.799 FF, 1.07.810 FF, 1.08.05 FF, 1.08.06 FF, 1.08.07 FF, 1.09.03 FF, 1.09.07 FF | 0d |  |  |
